# CONSTRUCCION CALLE CANAL BARRIO EL CARMEN MNCP FONSECA

Schedule from MS Project, 2021-09-13 to 2022-08-17, 9 hours a day, costs in $.

## Calendars

- CALENDARIO_CALLE_CANAL: Mon-Fri 07:00-12:00, 13:00-17:00; Sat 07:00-13:00; Sun off. Exceptions (off unless hours are given): 2021-10-18 (DIA DE LA RAZA), 2021-11-01 (DIA DE LOS DIFUNTOS), 2021-11-15 (INDEPENDENCIA DE CARTAGENA), 2021-12-08 (DIA DE LA INMACULADA CONCEPCION), 2021-12-25 (DIA DE NAVIDAD), 2022-01-01 (AÑO NUEVO), 2022-01-10 (DIA DE LOS REYES MAGOS), 2022-03-21 (DIA DE SAN JOSE), 2022-04-14 to 2022-04-15 (SEMANA SANTA), 2022-05-01 (DIA DEL TRABAJADOR), 2022-05-17 (DIA DE LA ASCENCION), 2022-06-20 (DIA DEL CORPUS CRISTI), 2022-06-27 (DIA DEL SAGRADO CORAZON), 2022-07-04 (DIA DE SAN PEDRO Y SAN PABLO), 2022-07-20 (DIA DE LA INDEPENDENCIA), 2022-08-07 (DIA DE LA BATALLA DE BOYACA), 2022-08-15 (DIA DE LA ASUNCION DE LA VIRGEN).

## Resources

| Resource | Rate |
| --- | --- |
| DIRECTOR DEL PROYECTO | 26442 |
| GERENTE DE DISEÑO | 26442 |
| GERENTE DOCUMENTAL | 26442 |
| GERENTE DE LICITACIONES | 26442 |
| GERENTE OPERATIVO | 50000 |
| ING CIVIL SENIOR | 26442 |
| ING DE PAVIMENTO | 26442 |
| ARQUITECTO | 16827 |
| ING HIDRAULICO | 26442 |
| ING DE SUELOS | 26442 |
| ING DE ESTRUCTURAS | 26442 |
| CUADRILLA TOPOGRAFIA | 33653 |
| CUADRILLA DEMOLICION | 38461 |
| CUADRILLA MOVIMIENTO TIERRAS | 52884 |
| CUADRILLA OBRA CIVIL | 52884 |
| CUADRILLA INSTALACION TUBERIA | 43269 |
| ALMACENISTA | 8653 |

## Schedule

| ID | WBS | Task | Type | Duration | Start | Finish | Predecessors | Baseline start | Baseline finish | Baseline duration | Total slack | Resources | Work | Cost |
| --- | --- | --- | --- | --- | --- | --- | --- | --- | --- | --- | --- | --- | --- | --- |
| 1 | 1 | **Construcción de una calle-canal en el barrio el Carmen en el municipio de Fonseca en el departamento de La Guajira** |  | 259d | 2021-09-13 | 2022-08-17 |  | 2021-09-13 | 2022-12-02 | 343d | 0d |  | 25074h | 1,012,408,866 |
| 2 | 1.1 | INICIO | milestone | 0d | 2021-09-13 | 2021-09-13 |  |  |  |  | 0d | DIRECTOR DEL PROYECTO; GERENTE DE LICITACIONES; ING CIVIL SENIOR; ARQUITECTO; GERENTE DE DISEÑO; GERENTE DOCUMENTAL; GERENTE OPERATIVO; ING DE ESTRUCTURAS; ING DE PAVIMENTO; ING DE SUELOS; ING HIDRAULICO |  |  |
| 3 | 1.2 | **ETAPA PRECONTRACTUAL** |  | 42d | 2021-09-13 | 2021-11-05 |  | 2021-09-13 | 2021-11-05 | 42d | 0d |  | 1134h | 29,985,228 |
| 4 | 1.2.1 | Precontractual |  | 42d | 2021-09-13 | 2021-11-05 | 2 | 2021-09-13 | 2021-11-05 | 42d | 0d | DIRECTOR DEL PROYECTO; GERENTE DE LICITACIONES; GERENTE DOCUMENTAL | 1134h | 29,985,228 |
| 5 | 1.3 | **REALIZAR PRELIMINARES** |  | 210d | 2021-11-05 | 2022-08-06 |  | 2021-11-05 | 2022-08-06 | 210d | 7d |  | 1890h | 63,604,170 |
| 6 | 1.3.1 | Localización y replanteo |  | 210d | 2021-11-05 | 2022-08-06 | 4 | 2021-11-05 | 2022-08-06 | 210d | 7d | CUADRILLA TOPOGRAFIA | 1890h | 63,604,170 |
| 7 | 1.4 | **REALIZAR DEMOLICIONES** |  | 35d | 2021-11-16 | 2021-12-30 |  | 2021-11-16 | 2022-05-19 | 143d | 0d |  | 315h | 12,115,215 |
| 8 | 1.4.1 | Demolición de estructuras |  | 14d | 2021-11-16 | 2021-12-02 | 4FS+7d | 2021-11-16 | 2021-12-02 | 14d | 0d | CUADRILLA DEMOLICION | 126h | 4,846,086 |
| 9 | 1.4.2 | Corte de pavimento rígido |  | 14d | 2021-12-02 | 2021-12-21 | 8 | 2021-11-24 | 2021-12-13 | 14d | 0d | CUADRILLA DEMOLICION | 126h | 4,846,086 |
| 10 | 1.4.3 | Demolición de pavimento |  | 7d | 2021-12-21 | 2021-12-30 | 9 | 2022-05-10 | 2022-05-19 | 7d | 0d | CUADRILLA DEMOLICION | 63h | 2,423,043 |
| 11 | 1.5 | **REALIZAR MOVIMIENTO DE TIERRAS** |  | 119d | 2021-12-30 | 2022-06-02 |  | 2021-11-24 | 2022-05-14 | 133d | 56d |  | 5481h | 289,857,204 |
| 12 | 1.5.1 | Excavación para zanja de instalación y conformación de subrasante. Incluye Retiro |  | 119d | 2021-12-30 | 2022-06-02 | 10 | 2021-11-24 | 2022-04-27 | 119d | 56d | CUADRILLA MOVIMIENTO TIERRAS | 1071h | 56,638,764 |
| 13 | 1.5.2 | Base estabilizada con cemento |  | 63d | 2021-12-30 | 2022-03-22 | 10 | 2021-12-02 | 2022-02-22 | 63d | 112d | CUADRILLA MOVIMIENTO TIERRAS | 567h | 29,985,228 |
| 14 | 1.5.3 | Separación de suelos de cimentación y capas granulares con geotextil |  | 56d | 2021-12-30 | 2022-03-11 | 10 | 2021-12-21 | 2022-03-03 | 56d | 119d | CUADRILLA MOVIMIENTO TIERRAS | 504h | 26,653,536 |
| 15 | 1.5.4 | Subbase granular tipo B - SGB |  | 70d | 2022-01-11 | 2022-04-07 | 10FS+7d | 2022-01-11 | 2022-04-07 | 70d | 98d | CUADRILLA MOVIMIENTO TIERRAS | 630h | 33,316,920 |
| 16 | 1.5.5 | Relleno con material de préstamo para estructura de cimentación de tubería |  | 98d | 2021-12-30 | 2022-05-06 | 10 | 2021-12-30 | 2022-05-06 | 98d | 77d | CUADRILLA MOVIMIENTO TIERRAS | 882h | 46,643,688 |
| 17 | 1.5.6 | Relleno con material de préstamo |  | 119d | 2021-12-30 | 2022-06-02 | 10 | 2021-12-13 | 2022-05-14 | 119d | 56d | CUADRILLA MOVIMIENTO TIERRAS | 1071h | 56,638,764 |
| 18 | 1.5.7 | Entibado metálico tipo cajón |  | 84d | 2022-02-14 | 2022-06-02 | 10FS+35d | 2022-02-14 | 2022-04-07 | 42d | 56d | CUADRILLA MOVIMIENTO TIERRAS | 756h | 39,980,304 |
| 19 | 1.6 | **CONSTRUIR OBRAS CIVILES DE ALCANTARILLADO** |  | 70d | 2022-01-11 | 2022-04-07 |  | 2022-01-11 | 2022-12-02 | 252d | 21d |  | 2205h | 116,609,220 |
| 20 | 1.6.1 | Concreto f'c 28 Mpa, Descarga |  | 28d | 2022-02-05 | 2022-03-11 | 10FS+28d | 2022-01-27 | 2022-03-03 | 28d | 119d | CUADRILLA OBRA CIVIL | 252h | 13,326,768 |
| 21 | 1.6.2 | Concreto f'c 21.1 MPa |  | 42d | 2022-02-14 | 2022-04-07 | 10FS+35d | 2022-02-14 | 2022-04-07 | 42d | 98d | CUADRILLA OBRA CIVIL | 378h | 19,990,152 |
| 22 | 1.6.3 | Solado f'c 21.1 MPa |  | 28d | 2022-01-27 | 2022-03-03 | 10FS+21d | 2022-10-26 | 2022-12-02 | 28d | 126d | CUADRILLA OBRA CIVIL | 252h | 13,326,768 |
| 23 | 1.6.4 | Acero de refuerzo |  | 28d | 2022-02-05 | 2022-03-11 | 10FS+28d | 2022-02-05 | 2022-03-11 | 28d | 0d | CUADRILLA OBRA CIVIL | 252h | 13,326,768 |
| 24 | 1.6.5 | Juntas de expansión |  | 14d | 2022-02-05 | 2022-02-22 | 10FS+28d | 2022-02-05 | 2022-02-22 | 14d | 133d | CUADRILLA OBRA CIVIL | 126h | 6,663,384 |
| 25 | 1.6.6 | Juntas de contracción |  | 21d | 2022-02-05 | 2022-03-03 | 10FS+28d | 2022-02-05 | 2022-03-03 | 21d | 126d | CUADRILLA OBRA CIVIL | 189h | 9,995,076 |
| 26 | 1.6.7 | Construcción de Cámara de Inspección TIPO II-A en concreto f'c 28 MPa, altura 2 < h < 3 m, diámetro interno de Ø 1.50 m; incluye placa base, cañuela, cono y tapa HD de seguridad |  | 21d | 2022-01-11 | 2022-02-04 | 10FS+7d | 2022-01-11 | 2022-02-04 | 21d | 147d | CUADRILLA OBRA CIVIL | 189h | 9,995,076 |
| 27 | 1.6.8 | Construcción de Caja de transición e Inspección en concreto f'c 28 MPa 2 x 2m, incluye pozo de diámetro interno de Ø 1.20m; placa base y cañuela, cono y tapa HD de seguridad |  | 21d | 2022-01-19 | 2022-02-14 | 10FS+14d | 2022-01-19 | 2022-02-14 | 21d | 140d | CUADRILLA OBRA CIVIL | 189h | 9,995,076 |
| 28 | 1.6.9 | Construcción de sumidero TIPO SR - II, en concreto f'c 28 MPa; incluye rejilla para cruce vehicular de 400 KN, 600x1000x44 y cárcamo longitud 2 < L < 4 m |  | 21d | 2022-01-19 | 2022-02-14 | 10FS+14d | 2022-01-19 | 2022-02-14 | 21d | 140d | CUADRILLA OBRA CIVIL | 189h | 9,995,076 |
| 29 | 1.6.10 | Construcción de sumidero TIPO ST - II, en concreto f'c 28 MPa; incluye rejilla para cruce vehicular de 400 KN, 600x1000x44 y cárcamo longitud 5 < L < 8 m |  | 21d | 2022-01-19 | 2022-02-14 | 10FS+14d | 2022-01-19 | 2022-02-14 | 21d | 140d | CUADRILLA OBRA CIVIL | 189h | 9,995,076 |

Notes:
- 1: Construcción de una vía-canal en el barrio el Carmen en el municipio de Fonseca entre las KR 9 Y 5 con CL 14 Y desde la CL 14 hasta el río ranchería con KR 5 para mitigar el riesgo de inundación y mejorar los problemas de movilidad del barrio el Carmen.

| ID | WBS | Task | Duration | Start | Finish | Predecessors | Baseline start | Baseline finish | Baseline duration | Total slack | Resources | Work | Cost |
| --- | --- | --- | --- | --- | --- | --- | --- | --- | --- | --- | --- | --- | --- |
| 30 | 1.7 | **INSTALAR TUBERÍAS** | 119d | 2022-01-11 | 2022-06-10 |  | 2022-01-11 | 2022-06-10 | 119d | 49d |  | 6363h | 275,320,647 |
| 31 | 1.7.1 | Instalación tuberías Alcantarillado tipo PVC Ø12" | 14d | 2022-01-19 | 2022-02-04 | 10FS+14d | 2022-01-19 | 2022-02-04 | 14d | 147d | CUADRILLA INSTALACION TUBERIA | 126h | 5,451,894 |
| 32 | 1.7.2 | Instalación tuberías Alcantarillado tipo PVC Ø18" | 21d | 2022-01-19 | 2022-02-14 | 10FS+14d | 2022-01-19 | 2022-02-14 | 21d | 140d | CUADRILLA INSTALACION TUBERIA | 189h | 8,177,841 |
| 33 | 1.7.3 | Instalación tuberías Alcantarillado tipo PVC Ø27" | 35d | 2022-01-19 | 2022-03-03 | 10FS+14d | 2022-01-19 | 2022-03-03 | 35d | 126d | CUADRILLA INSTALACION TUBERIA | 315h | 13,629,735 |
| 34 | 1.7.4 | Instalación tuberías Alcantarillado tipo PVC Ø30" | 14d | 2022-02-05 | 2022-02-22 | 10FS+28d | 2022-02-05 | 2022-02-22 | 14d | 133d | CUADRILLA INSTALACION TUBERIA | 126h | 5,451,894 |
| 35 | 1.7.5 | Instalación tuberías Alcantarillado tipo PVC Ø45" | 28d | 2022-02-14 | 2022-03-22 | 10FS+35d | 2022-02-14 | 2022-03-22 | 28d | 112d | CUADRILLA INSTALACION TUBERIA | 252h | 10,903,788 |
| 36 | 1.7.6 | Instalación tuberías Alcantarillado tipo PVC Ø48" | 28d | 2022-02-14 | 2022-03-22 | 10FS+35d | 2022-02-14 | 2022-03-22 | 28d | 112d | CUADRILLA INSTALACION TUBERIA | 252h | 10,903,788 |
| 37 | 1.7.7 | Instalación tuberías Alcantarillado tipo PVC Ø51" | 28d | 2022-02-14 | 2022-03-22 | 10FS+35d | 2022-02-14 | 2022-03-22 | 28d | 112d | CUADRILLA INSTALACION TUBERIA | 252h | 10,903,788 |
| 38 | 1.7.8 | Instalación tuberías Alcantarillado tipo PVC Ø54" | 28d | 2022-03-03 | 2022-04-07 | 10FS+49d | 2022-03-03 | 2022-04-07 | 28d | 98d | CUADRILLA INSTALACION TUBERIA | 252h | 10,903,788 |
| 39 | 1.7.9 | Instalación tuberías Alcantarillado tipo PVC Ø60" | 56d | 2022-03-22 | 2022-06-02 | 10FS+63d | 2022-03-22 | 2022-06-02 | 56d | 56d | CUADRILLA INSTALACION TUBERIA | 504h | 21,807,576 |
| 40 | 1.7.10 | Abatimiento de agua y control de escorrentía con Ataguía | 119d | 2022-01-11 | 2022-06-10 | 10FS+7d | 2022-01-11 | 2022-06-10 | 119d | 49d | CUADRILLA INSTALACION TUBERIA | 1071h | 46,341,099 |
| 41 | 1.7.11 | Reparación acometidas de acueducto | 112d | 2022-01-19 | 2022-06-10 | 10FS+14d | 2022-05-06 | 2022-06-10 | 28d | 49d | CUADRILLA INSTALACION TUBERIA | 1008h | 43,615,152 |
| 42 | 1.7.12 | Reparación de domiciliaria de alcantarillado sanitario | 112d | 2022-01-19 | 2022-06-10 | 10FS+14d | 2022-05-06 | 2022-06-10 | 28d | 49d | CUADRILLA INSTALACION TUBERIA | 1008h | 43,615,152 |
| 43 | 1.7.13 | Reparación de redes de gas natural | 112d | 2022-01-19 | 2022-06-10 | 10FS+14d | 2022-05-06 | 2022-06-10 | 28d | 49d | CUADRILLA INSTALACION TUBERIA | 1008h | 43,615,152 |
| 44 | 1.8 | **CONSTRUIR OBRAS CIVILES DE PAVIMENTOS Y PROTECCIÓN** | 119d | 2022-01-19 | 2022-06-21 |  | 2022-01-19 | 2022-07-19 | 140d | 42d |  | 2772h | 146,594,448 |
| 45 | 1.8.1 | Pavimento en concreto hidráulico MR=41 | 84d | 2022-01-19 | 2022-05-06 | 10FS+14d | 2022-01-19 | 2022-05-06 | 84d | 77d | CUADRILLA OBRA CIVIL | 756h | 39,980,304 |
| 46 | 1.8.2 | Acero de refuerzo | 56d | 2022-01-27 | 2022-04-07 | 10FS+21d | 2022-01-27 | 2022-04-07 | 56d | 98d | CUADRILLA OBRA CIVIL | 504h | 26,653,536 |
| 47 | 1.8.3 | Andenes en concreto 3000 psi, e=0.10m | 56d | 2022-03-22 | 2022-06-02 | 23FS+7d | 2022-04-19 | 2022-06-30 | 56d | 56d | CUADRILLA OBRA CIVIL | 504h | 26,653,536 |
| 48 | 1.8.4 | Relleno en material seleccionado para andenes | 28d | 2022-05-06 | 2022-06-10 | 23FS+42d | 2022-06-02 | 2022-07-11 | 28d | 49d | CUADRILLA OBRA CIVIL | 252h | 13,326,768 |
| 49 | 1.8.5 | Bordillo en concreto | 35d | 2022-03-30 | 2022-05-14 | 23FS+14d | 2022-04-28 | 2022-06-10 | 35d | 70d | CUADRILLA OBRA CIVIL | 315h | 16,658,460 |
| 50 | 1.8.6 | Marcas viales horizontales en frio | 28d | 2022-05-16 | 2022-06-21 | 23FS+49d | 2022-06-11 | 2022-07-19 | 28d | 0d | CUADRILLA OBRA CIVIL | 252h | 13,326,768 |
| 51 | 1.8.7 | Nivelación de tapas en pozos de inspección | 21d | 2022-05-06 | 2022-06-02 | 23FS+42d | 2022-06-02 | 2022-06-30 | 21d | 56d | CUADRILLA OBRA CIVIL | 189h | 9,995,076 |
| 52 | 1.9 | **SUMINISTRAR TUBERÍA** | 42d | 2021-11-05 | 2021-12-30 |  | 2021-11-05 | 2021-12-30 | 42d | 175d |  | 3402h | 29,437,506 |
| 53 | 1.9.1 | Suministro tuberías Alcantarillado tipo PVC Ø12" | 42d | 2021-11-05 | 2021-12-30 | 4 | 2021-11-05 | 2021-12-30 | 42d | 175d | ALMACENISTA | 378h | 3,270,834 |
| 54 | 1.9.2 | Suministro tuberías Alcantarillado tipo PVC Ø18" | 42d | 2021-11-05 | 2021-12-30 | 4 | 2021-11-05 | 2021-12-30 | 42d | 175d | ALMACENISTA | 378h | 3,270,834 |
| 55 | 1.9.3 | Suministro tuberías Alcantarillado tipo PVC Ø27" | 42d | 2021-11-05 | 2021-12-30 | 4 | 2021-11-05 | 2021-12-30 | 42d | 175d | ALMACENISTA | 378h | 3,270,834 |
| 56 | 1.9.4 | Suministro tuberías Alcantarillado tipo PVC Ø30" | 42d | 2021-11-05 | 2021-12-30 | 4 | 2021-11-05 | 2021-12-30 | 42d | 175d | ALMACENISTA | 378h | 3,270,834 |
| 57 | 1.9.5 | Suministro tuberías Alcantarillado tipo PVC Ø45" | 42d | 2021-11-05 | 2021-12-30 | 4 | 2021-11-05 | 2021-12-30 | 42d | 175d | ALMACENISTA | 378h | 3,270,834 |
| 58 | 1.9.6 | Suministro tuberías Alcantarillado tipo PVC Ø48" | 42d | 2021-11-05 | 2021-12-30 | 4 | 2021-11-05 | 2021-12-30 | 42d | 175d | ALMACENISTA | 378h | 3,270,834 |
| 59 | 1.9.7 | Suministro tuberías Alcantarillado tipo PVC Ø51" | 42d | 2021-11-05 | 2021-12-30 | 4 | 2021-11-05 | 2021-12-30 | 42d | 175d | ALMACENISTA | 378h | 3,270,834 |
| 60 | 1.9.8 | Suministro tuberías Alcantarillado tipo PVC Ø54" | 42d | 2021-11-05 | 2021-12-30 | 4 | 2021-11-05 | 2021-12-30 | 42d | 175d | ALMACENISTA | 378h | 3,270,834 |
| 61 | 1.9.9 | Suministro tuberías Alcantarillado tipo PVC Ø60" | 42d | 2021-11-05 | 2021-12-30 | 4 | 2021-11-05 | 2021-12-30 | 42d | 175d | ALMACENISTA | 378h | 3,270,834 |

| ID | WBS | Task | Type | Duration | Start | Finish | Predecessors | Baseline start | Baseline finish | Baseline duration | Total slack | Resources | Work | Cost |
| --- | --- | --- | --- | --- | --- | --- | --- | --- | --- | --- | --- | --- | --- | --- |
| 62 | 1.10 | **CEIRRE FINANCIERO** |  | 42d | 2022-06-21 | 2022-08-17 |  | 2021-11-05 | 2022-08-25 | 224d | 0d |  | 1512h | 48,885,228 |
| 63 | 1.10.1 | Cierre Financiero |  | 42d | 2022-06-21 | 2022-08-17 | 50 | 2021-11-05 | 2022-08-25 | 224d | 0d | DIRECTOR DEL PROYECTO; GERENTE DOCUMENTAL; GERENTE OPERATIVO; ING CIVIL SENIOR | 1512h | 48,885,228 |
| 64 | 1.11 | FIN | milestone | 0d | 2022-08-17 | 2022-08-17 | 63 |  |  |  | 0d | DIRECTOR DEL PROYECTO; GERENTE DE LICITACIONES; ING CIVIL SENIOR |  |  |
